# 3GPP_Release-2000

Schedule from MS Project, 2000-01-03 to 2013-12-24, A marks actual dates.

## Calendars

- Standard: Mon-Fri 08:00-12:00, 13:00-17:00; Sat-Sun off. Exceptions (off unless hours are given): 2000-01-15 08:00-12:00, 13:00-17:00, 2009-05-30 08:00-12:00, 13:00-17:00, 2011-08-27 to 2011-08-28 08:00-12:00, 13:00-17:00, 2011-09-24 08:00-12:00, 13:00-17:00.

## Resources

| Resource |
| --- |
| NP |
| N1 |
| N2 |
| N3 |
| N4 |
| N5 |
| TP |
| T1 |
| T2 |
| T3 |
| RP |
| R1 |
| R2 |
| R3 |
| R4 |
| SP |
| S1 |
| S2 |
| S3 |
| S4 |
| S5 |
| PCG |
| GP |
| No |
| CN4 |
| ? |
| WG G2 |
| G2 |
| G1 |
| G4 |
| G3 |
| All |
| Generic |
| MLST |
| G5 |
| S3, G2 |
| WG T2 |
| GP,G1 |
| G4,G5 |
| OMA |
| GP-G2 |
| Yes |
| GP, |
| N4, |
| GP, N1 |
| CT5 |
| C5 |
| C1 |
| C4 |
| C3 |
| C6 |
| G1, |
| 4 |
| ct |
| c,s,r |
| CT,RAN,SA |
| G2, |
| G1, G3 |
| CT6 |
| CT1 |
| CT1, CT3, CT4 |
| C1, C3, C4 |
| CP |
| R5 |
| C |
| Rel-8 |
| GP, G2 |
| R1,R4 |
| S5,C1 |
| CT,RAN,SA,GERAN |
| S3,C1,C4 |
| 5 |
| S1,C1,C3,C4,S5 |
| S1,C1,C3,C5 |
| S1,C1,C3,C4 |
| S1,S5 |
| S2,S3 |
| RAN,SA |
| RP,S5 |
| S2,CT |
| S1,CT |
| S1,CT,GERAN |
| S1,C5 |
| S3,CT |
| S4,CT |
| C1,SA |
| S1,S2 |
| S1,S4 |
| S2,S2,S3,CT |
| S2,S3,CT |
| S1,CT,GX |
| S1,S4,CT |
| S2,S2,S3,S5,CT |
| S1,S2,CT |
| S1,S2,S3,CT |
| S1,S2,S3,S5CT |
| S1,S2,S3,S5,CT |
| S2,S5,CT |
| S4,S3 |
| S1,C1 |
| CP,C1 |
| C1,C3 |
| C1,C3,C4 |
| S1,S5,CT |
| C4,C3 |
| CP,RAN,SA,GERAN |
| S1,S2,S3,S5,CP |
| S2,S3,CP |
| S2,CP |
| S1,CP,GX |
| S1,CP |
| S1,S4,CP |
| S1,S2,CP |
| S1,S2,S3,CP |
| S2,S5,CP |
| S3,CP |
| S1,S5,CP |
| RAN,SA,GERAN |
| S1,S2,S3,S5,C1,C3,C4,C6 |
| S2,S3,C1,C3,C4 |
| S2,C4 |
| S2,C1,C3,C4 |
| S2,C1,C4 |
| S2,S3,C1,C4 |
| S1,C1,C4,G2 |
| C1,C4 |
| S1,C1,C3 |
| S1,S4,C1,C3,C4 |
| S1,S2,S3,C1,C3,C4 |
| S2,S5,C3 |
| S1,S2,C1,C4 |
| S2,C1 |
| S2,C1,C3 |
| S3,C1,C3,C4 |
| S1,S5,C1,C3,C4 |
| S2,C3,C4 |
| C3,C1 |
| R2,R4 |
| R2,R5 |
| RP,R5 |
| RP,S5,R5 |
| R1,R5 |
| S1,C1,R5 |
| S1,C1,S4,R5 |
| GERAN |
| G3new |
| G1, G3new |
| C4,C1,C3 |
| R1.R4 |
| R1, R4 |
| R2,R3 |
| C3,C4 |
| S4,C3 |
| S4,C3,C1,C4 |
| S1,S2,C1 |
| S1,S2<C1,C3,C4 |
| S1,S2,C1,C3,C4 |
| S5,C1,C3,C4 |
| GP,C4 |
| C4,C1 |
| S2,S1 |
| RP,SP,GP |
| RP,SP,CP,GP |
| CP,GP,RP,SP |
| GP,C4,S4 |
| S1,C1,C4 |
| S1,S2,C3,C1 |
| R2,R4,R3 |
| CP,GP, RP,SP |
| S2,S1,C1,S5 |
| S2,S1,C1 |
| S1,C1,S4 |
| S1,S2,GP,C4,R2 |
| S1,GP,R2 |
| S1,C6 |
| S1,S2,C1,S4 |
| S2,S3,S5,C1,C3,C4 |
| S2,S5,C1 |
| S2,S3,S5 |
| CP,GP, RP,SP,TP |
| S2,C4,C1 |
| S1,C1,C4,S3 |
| S2,S5 |
| S3,C1 |
| S3,C4 |
| S1,C4 |
| S2,S5,C3,C1 |
| S2,S1,S5,C1,C4 |
| S1,R1,C3 |
| S1,C1,R2 |
| S2,S1,C1,C4 |
| S1,C1,C6 |
| GP,S4,C4,C1,C3 |
| C3,C1,C4 |
| S1,C4,C1 |
| S1,S3 |
| S1,S2,S5,C3,C4 |
| R4,G1 |
| G1,R4 |
| RP,GP |
| R4,GP |
| R3,R2 |
| C6,RP,SP |
| R5,C6 |
| CP,RP,SP |
| RP,SP,CP |
| R3,S5 |
| S1,S2,RP |
| S1,S2,S5,RP |
| S2,S1,RP |
| Rel-9 |
| S3,C6 |
| S1,S2,S3,S5,RP |
| S2,S1,S3 |
| S1,S2,S3 |
| S1,S2,S3,S5 |
| C6,R5 |
| S1,S2,RP,GP |
| S1,S2,S4,S5,RP,GP |
| GP,G2 |
| GP,GP, N1 |
| GP,S2,G1,G2 |
| GP,R2,R3,S2,G1,G2 |
| GP,S2,S5,R2,R3,G2,G1 |
| GP,R3 |
| N4,S2 |
| GP,RP |
| GP,S2,RP |
| G5,G4 |
| G4,R3 |
| S2,R2,R4 |
| S1,S2,R2,R4 |
| GP,S5 |
| S1,S2,S5 |
| R4,R5 |
| R4,R2,R3,R5 |
| S2,S5,N4,RP |
| S1,S2,S3,S5,NP |
| S2,S4,S5 |
| T2,S1,S4,S5 |
| SP,RP |
| S2,RP |
| S1,S2,CP,G2 |
| CP,SP |
| S1,G2 |
| SP,CP |
| S1,S2,S5,C3 |
| S1,C1,S3 |
| G1,G3new |
| C4, C3, C1C4 |
| C4,C3,C1 |
| S1,S2,S3,S5,R2,R3,R4 |
| S1,S2,S3,R2 |
| S2,S3,S5,C4,R2 |
| S1,S5,C1 |
| S1,S2,S3,C1,C3,C4,R2 |
| Ggp |
| S3,S2,C1,C4,G2 G3new |
| R1,R2,R3,R4 |
| R4,R1,R2,R3 |
| R4,R2,R3 |
| S1,C1,C4,R2 |
| R4,R2 |
| S2,C4,R2,R4 |
| S2,C4,R2 |
| S2,S3,S5,C3,C4,R2 |
| S1,S2,S4,T2 |
| S1,S2,S4 |
| S1,S2,S4,R5 |
| S3,S2,C1,C4,G2,G3new |
| GP,C1 |
| S1,S5,C4 |
| S1,S2,S3,S5,R2,R3,R4,GP |
| GP,C4,C3,C1 |
| SMG9 |
| SMG1 |
| SMG2 |
| N3,R5 |
| N1, N2, N4, G1, G2, R3, S1, SMG2 |
| S1,SMG1 |
| SMG1,N4 |
| N1,C1,N4,S1,T2,G2,SMG1,SMG2,SMG3,SMG7,SMG9 |
| SMG1,N2 |
| S1,S2,N2,N4 |
| N4,N2 |
| G1,G2 |
| G1,G2,C1 |
| G1,G2,N1 |
| SMG2, SMG1, SMG3, SMG4, SMG7, SMG9, SMG10, G1, G2, G3, N1, N3, T2 |
| SMG2,G1 |
| S1,G1,G2 |
| SMG1,N1,G1,G2 |
| G2,G1 |
| G1,G2,G3,S1,S2,SMG1,SMG2,SMG7,N1,N2,N3,N4,T2 |
| 23.003, 23.008, 29.060 |
| S1, S2, SMG1, SMG2, SMG12, G2, N1, N2, N4 |
| S1,S2,SMG1,SMG2,SMG12,G2,N1,N2,N4 |
| S1,SMG2,N1,N2,N4 |
| SMG1,T2 |
| S1,N1,N2,N4 |
| S1,S2,N5 |
| SMG2,SMG7,G2,T2 |
| S3,N1,N2,N3 |
| S3,N1,N2,N4 |
| SMG9,T3 |
| SMG2,SMG3,SMG7,G2,N2 |
| SMG2,N1,G1,G2 |
| S1,N2 |
| N1,N3 |
| S2,N1 |
| N1,N2,N4 |
| N2,N1,N4 |
| N2,N4 |
| S1,T3 |
| T2,N3 |
| S3,N2 |
| T2,S1 |
| S1,N4 |
| SMG1,SMG2,SMG7 |
| N1,S1,T1 |
| SMG1,SMG3 |
| N4,S2,N1 |
| S1,S2,SMG1,SMG2,SMG7,G1,G2,G3,N1,N2,N3,N4,T2 |
| SMG1,N3 |
| S1,N3 |
| CP,SP,SMG |
| CP,SP,TP,GP,SMG |
| NP,SP,TP,GP,SMG |
| NP,GP, RP,SP,TP |
| SMG2,SMG1,SMG3,SMG4,SMG7,SMG9,SMG10,G1,G2,G3,N1,N3,T2 |
| S1,N2,N4 |
| S1,S2,S3,C1,C3,C4,R2,R3 |
| R2,R3,R1,R4 |
| R2,R3,R4 |
| R2,R1,R3,R4 |
| S2,C4,R2,R3,R4 |
| S2,C4,R2,R1,R3,R4 |
| S2,S3,S5,C3,C4,R2,R3,R4 |
| R1,R2,R4 |
| R3,R1,R4 |
| S2, |
| S2,G2, |
| S1,S2,G2, |
| S1,S2,G2,R2,R3, |
| S1,S2,C4,G2,R2,R3 |
| S1,S2,N4,G2,R2,R3 |
| S1,S2,SMG1,SMG2,SMG12,G2,N1,N2,N4,R2,R3 |
| S1,SMG1,T2 |
| S1,SMG1,S2 |
| S1,N4,N2 |
| T2,N1,N3 |
| S3,N2,N4 |
| SMG1,SMG2,SMG3,SMG7,SMG9,N1,C1,N4,S1,T2,G2 |
| SMG1,N2,N4 |
| S2,T2,N1,N2,N4 |
| S1,T2 |
| S1,S2,C4 |
| S1,S2,N4,RP |
| S2,N4 |
| S1,S2,N3,N4,RP |
| S1,S2,SMG1,SMG2,SMG12,T2,G2,N1,N2,N4,R2,R3 |
| S1,T2,N1,N3 |
| S1,S2,SMG1,SMG2,SMG12,T2,G2,N1,N2,N3,N4,R2,R3 |
| S1,S2,S3,SMG1,SMG2,SMG12,G2,N1,N2,N4,R2,R3 |
| S1,S2,SMG,G1,G2,G3,N1,N2,N3,N4,T2 |
| S1,S2,SMG,T2,G2,N1,N2,N3,N4,R2,R3 |
| S1,S3,SMG,G1,G2,G3,N1,N2,N3,N4,T2 |
| S1,S3,T2,N2,N4 |
| S1,S2,SMG,T2,G1,G2,G3,N1,N2,N3,N4 |
| G2,S2 |
| T1,R5 |
| R5,T1 |
| S1,S2,S4,T1,R5 |
| S1,S2,S4,S5,T1,RP,GP |
| S1,S2,S3,S5,R2,R3,R4,GP,C1 |
| S1,S2,S3,SMG1,SMG2,SMG12,N1,N2,N4,R2,R3 |
| S1,S2,SMG,T2,N1,N2,N3,N4,R2,R3 |
| NP,SP,TP,SMG |
| S1,S2,SMG,T2,N1,N2,N3,N4 |
| SMG,N1 |
| SMG |
| S1,S2,SMG1,SMG2,SMG7,N1,N2,N3,N4,T2 |
| SMG2,SMG1,SMG3,SMG4,SMG7,SMG9,SMG10,N1,N3,T2 |
| S1,SMG |
| SMG2,SMG7,T2 |
| SMG2,S2 |
| N1,N2,N4,R3,S1,SMG |
| SMG2,SMG3,SMG7,N2 |
| SMG1,SMG2,SMG3,SMG7,SMG9,N1,C1,N4,S1,T2 |
| S1,S2,SMG,N3,N4,RP |
| S1,S2,S4,SMG,N3,N4,RP |
| S2,C1,C4,R2,R1,R3,R4 |
| R2,S2,S4 |
| G3new,R5 |
| GP,R4 |
| S2,S4,R2 |
| SP,GP |
| RP,SP |
| S2,S1,S3,S5 |
| S3,S1 |
| N4,N1,N2,S2 |
| S2,G1,G2,R2,R3 |
| S2,G1,G2 |
| G1,G2,R2,R3 |
| N4,T3 |
| S3,S2,N1,N4,T3,OMA |
| T2,S1,S4,S5,OMA |
| S2,N3 |
| S4,S1 |
| N4,N3,S1 |
| R5,G3new |
| R4,R2,R1 |
| S2,R2 |
| C3, C4,C1 |
| S3,C1,C4,C3 |
| C1,C4,C3 |
| S2,C1,C4,C3 |
| R3,R5 |
| S1,S2,C3 |
| R1,R2 |
| S3,C1,C4,G2,G3new |
| R1,R3 |
| GP,N1 |
| R1,R2,R3 |
| R3,R2,R4 |
| R4,R3 |
| S1,S2,R2,R3 |
| S1,S2,S3,C1,C3,C4,R2,R3,R5 |
| S2,S1,S5 |
| C4, C1 |
| C3, C1, C4 |
| S2,S1,S3,S5,C4,C1 |
| S2,C3,C1,C4 |
| S2,S1,S5,C3 |
| GP,S2,C1 |
| GP,S2,C1,G2 |
| G2,S2,C1 |
| v |
| G3new,G1,G2 |
| G1,G2,C1,G3new |
| S2,S1,S5,C1,C3 |
| C1,C3,C4,R5 |
| R2,R1 |
| S1<S2,N1,R2,R5 |
| S1,S2,N1,R2,R5 |
| S2,R5 |
| S1,S2,S5,R5 |
| S2,C1,C4,R2,R1,R3,R4,R5 |
| S1,S2,S3,S5,NP,R5 |
| S1,S2,S4,S5,RP,R5,GP |
| S1,S2,S3,S5,C1,C6,R2,R3,R4 |
| S1,S2,S3,S5,C1,C6,R2,R3,R4,GP |
| S4,R2 |
| S1,S2,C1,C4,G2 |
| S4,C3,C4 |
| S5,C1,C4 |
| S2,C4,C3,C1 |
| C4, C3, C1 |
| S2,S4,R2,C4,C3,C1 |
| GP1,GP2 |
| GP,GP1,GP2 |
| GP,G1,G2 |
| G2,R3 |
| S1,S2,S3,C1,C3,C4,G2 |
| GP,G1,C1 |
| S1,S2,C4,C3,C1 |
| - |
| GP,G1,G2,G3new |
| S1,S2,S3,C1,C3,C4,G2,R2,R3 |
| S1,S2,C1,C3,C4,G2,R2,R3 |
| C1,C6 |
| GP,G2,C4 |
| S2,C3 |
| R5,R4 |
| C4,GP,G2 |
| S1,S2,C1,C4,G2,R2,R3 |
| R1,R2,R4,S3 |
| S2,S5,C3,C1,C4 |
| S2,S4,C4,C3,C1 |
| S2,S4 |
| S3,S1,S2 |
| S1,S2,S3,C1,R2 |
| S3,S1,S2,C1,R2 |
| S2,C3,S5 |
| S1,S2,C1,C4,C3,G2,R2,R3 |
| S5,C4 |
| S2,S1,C3 |
| C1,C4,C3,C6 |
| S1,S2,C1,C4,C3,C6,G2,R2,R3 |
| R1,R2,R4,S3,C4,C6 |
| R4,R1,R4,R1,R2,R3,R3 |
| S2,R3,R2 |
| S1,S2,S5,CP |
| S1,S3,CP |
| C6,C1 |
| R4,R2,R1,R3 |
| R3,R1,R2 |
| R1,R4,R2,R3 |
| S2,C4,C1,C3 |
| R3,R1,R2,R4 |
| C4,S1 |
| S2,S5,R3,GP, |
| S2,S5,R3,GP |
| S1,S2,S3,S5,C1,C3,C4 |
| S2,S3,S5,C1,C3,C4,C6 |
| S5,S1 |
| 03.06.2011 |
| CT1 CT3, CT4 |
| CT3, |
| CT4 |
| CT3 |
| GP,G2,G1 |
| S5,S1,C1 |
| SP,RP,CP |
| SP,CP,GP,RP |
| R1,R2,R4,R3 |
| R4,R2,R5 |
| R2,R4,R5 |
| R1,R2,R4,S2,S3,C4,C6 |
| C1-IETF |
| S4-IETF |
| C1-IETF, C3-IETF, C4-IETF |
| S3-IETF |
| C4-IETF |
| C1-IETF, C3-IETF |
| S2,S4,C1,R2 |
| S2,S4,C3,C4 |
| S2,S4,C1,C3,R2 |
| S1,S2,C1,IETF |
| S4,IETF |
| C1,C4,IETF |
| S2,S4,C1,C3,R2,IETF |
| S3,C1,C4,C3,IETF |
| S3,C4,IETF |
| C1,IETF |
| S1,S2,S3,S5,C1,C3,C4,C6,IETF |
| S2,S3,C1,C4,IETF |
| S1,S2,C1,C3,C4,IETF |
| C1,C3,C4,IETF |
| S1,S5,C1,C3,C4,IETF |
| C1,C3,IETF |
| S2,C1,C3,C4,IETF |
| S2,S4,C3,C4,IETF |
| S5,C1,C4,IETF |
| S5,C1,C3,C4,IETF |
| S2,S3,S5,C1,C3,C4,IETF |
| S2,IETF |
| S3,C1,C3,C4,IETF |
| S2,S3,C1,C3,C4,IETF |
| S3,S2 |
| S3,S2,C1 |
| S3,S1,S2,C1 |
| S2,S5,N3 |
| S1,S2,S3,S5,N1,N3,N4,T3 |
| S5,N4,R3 |
| S1,S2,S5,C1,C4,C3,C6,G2,R2,R3 |
| S2,N1,N4,R3,GP |
| T2,S3 |
| S3,N4,N1 |
| S2,N3,N4 |
| S3,T2 |
| S2,S1,S3,S5,RP,GP |
| S1,S2,S3,S5,R5 |
| S1,S2,S3,S5,NP,T3,T1,R5 |
| S3,T3 |
| GP,S3 |
| S1,S2,S3,S4,S5,RP,R5,GP |
| N1,N4 |
| S1,S2,S3,S4,N1,N3,N4,OMA |
| S2,C1,C3,C4,G2,R2,R3 |
| S1,C4,C3 |
| S2,S1,C1,C4,IETF |
| C1,C3,C4,C6 |
| C4,C1,C6 |
| S1,S2,S3,C1,C3,C4,C6 |
| S2,S1,C1,C3,C4 |
| S1,S2,C1,C3 |
| C1.IETF |
| C1-IETF,C4-IETF |
| G1,C1 |
| G1,S2,C4 |
| G2,S2,C4 |
| R1,R2,R3,R4,R5 |
| R2,R4,R3,R5 |
| R3,R2,R5 |
| R2,R3,C1,C6 |
| S1,S2,S3,C1,C3,C4,C6,R2,R3 |
| R4,R1 |
| S2,S4,C4,C3,C1,IETF |
| S2,C4,C3 |
| S3.C4,C1 |
| G2,C4 |
| R4,G1,G3new |
| C4,G2 |
| S3,C4,C1 |
| R2,R3,R5 |
| R1,R2,R4,R5 |
| S1,S2,S3,S5,C1,C6,R2,R3,R4,R5,GP |
| S1,C1,C4,R2,R5 |
| S2,S3,S5,C3,C4,R2,R3,R4,R5 |
| R2,R1,R3,R4,R5 |
| S3-IETF, C1-IETF |
| S3-IETF,C1-IETF |
| C1-IETF,C3-IETF |
| S2-IETF |
| S2,S1,C1,C3,C4,IETF |
| 25.101, 25.104, 25.141, 25.317 |
| S1,G2,S2,C1 |
| S1,C1,C4,R2,R3,R5 |
| S5,S2 |
| S4,C3,C4,IETF |
| S4,S3,C3,C4,IETF |
| S4,S3,C3,C4 |
| S4,S3,IETF |
| S1,S2,S3,S5,C1,C3,C4,C6,R2,R3 |
| C1,C4,C6 |
| S1,S2,S5,C1,C4,C6,G2,R2,R3 |
| GP,G1,C1,G3new |

## Schedule

| ID | WBS | Task | Type | Duration | Start | Finish | Complete | Remaining | Baseline start | Baseline finish | Baseline duration | Total slack | Constraint | Resources | Work | Actual work | Text6 | Text1 | Text2 | Text4 | Text5 | Text7 | Text8 |
| --- | --- | --- | --- | --- | --- | --- | --- | --- | --- | --- | --- | --- | --- | --- | --- | --- | --- | --- | --- | --- | --- | --- | --- |
| 1 | 1 | Extract for SA1#57 of the Work Plan Version 2012 Jan 24 | milestone | 0d? | 2000-01-03 A | 2000-01-03 A | 100% |  | 2000-01-03 | 2000-01-03 | 0d? |  | finish no earlier than 2000-01-03 | - |  |  |  |  |  |  |  |  |  |
| 2 | 2 | Rel-11 Stage 1 frozen 09/2011 | milestone | 0d? | 2000-01-03 A | 2000-01-03 A | 100% |  | 2000-01-03 | 2000-01-03 | 0d? |  | finish no earlier than 1998-12-07 | - |  |  |  |  |  |  |  |  |  |
| 3 | 3 | Rel-11 Stage 2 freeze 03/2012 | milestone | 0d? | 2000-01-03 A | 2000-01-03 A | 100% |  | 2000-01-03 | 2000-01-03 | 0d? |  | finish no earlier than 1998-12-07 | - |  |  |  |  |  |  |  |  |  |
| 4 | 4 | Rel-11 Stage 3 freeze 09/2012 | milestone | 0d? | 2000-01-03 A | 2000-01-03 A | 100% |  | 2000-01-03 | 2000-01-03 | 0d? |  | finish no earlier than 1998-12-07 | - |  |  |  |  |  |  |  |  |  |
| 5 | 5 | Gantt: dark blue=done; light blue=to be done; grey: previous values; black=summary | milestone | 0d? | 2000-01-03 A | 2000-01-03 A | 100% |  | 2000-01-03 | 2000-01-03 | 0d? |  | finish no earlier than 1998-12-07 | - |  |  |  |  |  |  |  |  |  |
| 6 | 6 | Release 12 Features |  | 590d? | 2011-09-22 | 2013-12-24 |  |  | 2011-09-22 | 2013-12-24 | 590d? | 0d | finish no earlier than 2013-12-24 | SP,CP | 4720h |  | Rel-12 |  |  |  |  |  |  |
| 7 | 7 | **IMS-based Telepresence** |  | 196d? | 2011-09-22 A | 2012-06-20 | 50% | 98d? | 2011-09-22 | 2012-06-20 | 196d? | 394d |  | S1 | 3136h | 1568h | Rel-12 | IMS_TELEP | PCG-27 | Orange | bruno.tossou@orange-ftgroup.com | SP-53 |  |
| 8 | 7.1 | Stage 1 for IMS-based Telepresence |  | 196d? | 2011-09-22 A | 2012-06-20 | 50% | 98d? | 2011-09-22 | 2012-06-20 | 196d? | 394d | finish no earlier than 2012-06-20 | S1 | 1568h | 784h | Rel-12 | IMS_TELEP | PCG-27 | Orange | bruno.tossou@orange-ftgroup.com | SP-53 |  |
| 9 | 8 | **Service and Media Reachability for Users over Restrictive Firewalls** |  | 197d? | 2011-09-21 A | 2012-06-20 | 20% | 157.6d? | 2011-09-21 | 2012-06-20 | 197d? | 394d |  | S1 | 3152h | 630.4h | Rel-12 | SMURFs | PCG-27 | Vodafone | mona.mustapha@vodafone.com | SP-53 |  |
| 10 | 8.1 | Stage 1 for Service and Media Reachability for Users over Restrictive Firewalls |  | 197d? | 2011-09-21 A | 2012-06-20 | 20% | 157.6d? | 2011-09-21 | 2012-06-20 | 197d? | 394d | finish no earlier than 2012-06-20 | S1 | 1576h | 315.2h | Rel-12 | SMURFs | PCG-27 | Vodafone | mona.mustapha@vodafone.com | SP-53 |  |
| 11 | 9 | **Codec for Enhanced Voice Services** |  | 915d? | 2010-03-25 A | 2013-09-20 | 40% | 548.4d? | 2010-03-25 | 2013-09-20 | 915d? | 67d |  | S4,S1 | 14648h | 5868.79h | Rel-12 | EVS_codec | PCG-24 | Huawei | anisse.taleb@huawei.com | SP-47 | Paolo |
| 12 | 9.1 | Stage 1 for Codec for Enhanced Voice Services |  | 1d? | 2010-03-25 A | 2010-03-25 A | 100% |  | 2010-03-25 | 2010-03-25 | 1d? |  | start no earlier than 2010-03-25 | S1 | 8h | 8h | Rel-12 | EVS_codec | PCG-24 | Huawei | anisse.taleb@huawei.com | SP-47 | Paolo |
| 13 | 9.2 | Stage 2/3 for Codec for Enhanced Voice Services |  | 915d? | 2010-03-25 A | 2013-09-20 | 40% | 549d? | 2010-03-25 | 2013-09-20 | 915d? | 67d | finish no earlier than 2013-09-20 | S4 | 7320h | 2928h | Rel-12 | EVS_codec | PCG-24 | Huawei | anisse.taleb@huawei.com | SP-47 | Paolo |
| 14 | 10 | **LIPA Mobility and SIPTO at the Local Network** |  | 824d? | 2010-10-15 A | 2013-12-06 | 6% | 776.89d? | 2010-10-15 | 2013-12-06 | 824d? | 12d |  | S2,C4,C1 | 40813.6h | 1801.94h | Rel-12 | LIMONET | PCG-26 | Huawei | patrice.hede@huawei.com | SP-50 | Maurice |
| 15 | 10.1 | TR on Stage 2 for LIPA Mobility and SIPTO at the Local Network |  | 395.85d? | 2010-10-15 A | 2012-06-20 | 45% | 217.72d? | 2010-10-15 | 2012-06-20 | 395.85d? | 394d | finish no earlier than 2012-06-20 | S2 | 3166.8h | 1425.06h | Rel-12 | LIMONET | PCG-26 | Huawei | patrice.hede@huawei.com | SP-50 | Maurice |
| 16 | 10.2 | Stage 2 for LIPA Mobility and SIPTO at the Local Network |  | 395.85d? | 2010-10-15 | 2012-06-20 |  |  | 2010-10-15 | 2012-06-20 | 395.85d? | 394d | finish no earlier than 2012-06-20 | S2 | 3166.8h |  | Rel-12 | LIMONET | PCG-26 | Huawei | patrice.hede@huawei.com | SP-50 | Maurice |
| 17 | 10.3 | **Core Network aspects of SIPTO at the Local Network (Stage 3)** |  | 581d? | 2011-09-19 | 2013-12-06 |  |  | 2011-09-19 | 2013-12-06 | 581d? | 12d |  | C4,C1 | 13944h |  | Rel-12 | LIMONET-SIPTO | PCG-27 | Huawei | caixia.qi@huawei.com | CP-53 |  |
| 18 | 10.3.1 | CT4 part of Core Network aspects of SIPTO at the Local Network |  | 581d? | 2011-09-19 | 2013-12-06 |  |  | 2011-09-19 | 2013-12-06 | 581d? | 12d | finish no earlier than 2013-12-06 | C4 | 4648h |  | Rel-12 | LIMONET-SIPTO | PCG-27 | Huawei | caixia.qi@huawei.com | CP-53 |  |
| 19 | 10.3.2 | CT1 part of Core Network aspects of SIPTO at the Local Network |  | 581d? | 2011-09-19 | 2013-12-06 |  |  | 2011-09-19 | 2013-12-06 | 581d? | 12d | finish no earlier than 2013-12-06 | C1 | 4648h |  | Rel-12 | LIMONET-SIPTO | PCG-27 | Huawei | caixia.qi@huawei.com | CP-53 |  |
| 20 | 10.4 | **Core Network aspects of LIPA Mobility (Stage 3)** |  | 581d? | 2011-09-19 | 2013-12-06 |  |  | 2011-09-19 | 2013-12-06 | 581d? | 12d |  | C1,C4 | 13944h |  | Rel-12 | LIMONET-LIPA | PCG-27 | Huawei | christian.herrero@huawei.com | CP-53 |  |
| 21 | 10.4.1 | CT1 part of Core Network aspects of LIPA Mobility |  | 581d? | 2011-09-19 | 2013-12-06 |  |  | 2011-09-19 | 2013-12-06 | 581d? | 12d | finish no earlier than 2013-12-06 | C1 | 4648h |  | Rel-12 | LIMONET-LIPA | PCG-27 | Huawei | christian.herrero@huawei.com | CP-53 |  |
| 22 | 10.4.2 | CT4 part of Core Network aspects of LIPA Mobility |  | 581d? | 2011-09-19 | 2013-12-06 |  |  | 2011-09-19 | 2013-12-06 | 581d? | 12d | finish no earlier than 2013-12-06 | C4 | 4648h |  | Rel-12 | LIMONET-LIPA | PCG-27 | Huawei | christian.herrero@huawei.com | CP-53 |  |
| 23 | 11 | Release 12 Studies |  | 590d? | 2011-09-22 | 2013-12-24 |  |  | 2011-09-22 | 2013-12-24 | 590d? | 0d | finish no earlier than 2013-12-24 | SP,CP | 4720h |  | Rel-12 |  | PCG-27 |  |  | SP-53 |  |
| 24 | 12 | Study on UICC/USIM enhancements |  | 785d? | 2009-12-10 A | 2012-12-12 | 55% | 353.25d? | 2009-12-10 | 2012-12-12 | 785d? | 269d | finish no earlier than 2012-12-12 | S1 | 6280h | 3454h | Rel-12 | FS_U2e | PCG-24 | Giesecke & Devrient | ilario.macchi@gi-de.com | SP-46 | Alain |
| 25 | 13 | Study on Alternatives to E.164 for Machine-Type Communications |  | 588d? | 2010-03-25 A | 2012-06-20 | 80% | 117.6d? | 2010-03-25 | 2012-06-20 | 588d? | 394d | finish no earlier than 2012-06-20 | S1 | 4680h | 3739.2h | Rel-12 | FS_AMTC | PCG-24 | T-Mobile USA | gary.jones@T-Mobile.com | SP-47 | Alain |
| 26 | 14 | Study on enhancements for Machine-Type Communications (MTC) |  | 530d? | 2010-06-10 A | 2012-06-20 | 40% | 318d? | 2010-06-10 | 2012-06-20 | 530d? | 394d | finish no earlier than 2012-06-20 | S1 | 4240h | 1696h | Rel-12 | FS_MTCe | PCG-25 | Huawei | laurence.meriau@huawei.com | SP-48 | Alain |
| 27 | 15 | Study on Integration of Single Sign-On (SSO) frameworks with 3GPP networks |  | 383d? | 2010-09-23 A | 2012-03-07 | 95% | 19.15d? | 2010-09-23 | 2012-03-07 | 383d? | 469d | finish no earlier than 2011-09-08 | S1 | 3041.15h | 2889.09h | Rel-12 | FS_SSO_Int | PCG-25 | InterDigital | christopher.wallace@interdigital.com | SP-49 | Alain |
| 28 | 16 | Study on Continuity of Data Sessions to Local Networks |  | 262.85d? | 2010-12-16 A | 2011-12-14 A | 100% |  | 2010-12-16 | 2011-12-14 | 262.85d? |  | finish no earlier than 2011-12-14 | S1 | 2084.27h | 2084.27h | Rel-12 | FS_CSN | PCG-26 | NEC | joerg.swetina@nw.neclab.eu | SP-50 | Alain |
| 29 | 17 | Study on non-MTC Mobile Data Applications Impacts |  | 262.77d? | 2010-12-16 A | 2011-12-14 A | 100% |  | 2010-12-16 | 2011-12-14 | 262.77d? |  | finish no earlier than 2011-12-14 | S1 | 2083.59h | 2083.59h | Rel-12 | FS_MODAI | PCG-26 | Huawei, China Mobile | Amar Deol (adeol@huawei.com), Gang Li | SP-50 | Alain |
| 30 | 18 | Study on Proximity-based Services |  | 256d? | 2011-09-22 A | 2012-09-12 | 10% | 230.4d? | 2011-09-22 | 2012-09-12 | 256d? | 334d | finish no earlier than 2012-09-12 | S1 | 2048h | 204.8h | Rel-12 | FS_ProSe | PCG-27 | Qualcomm | Rich Hovey (rhovey@qualcomm.com) | SP-53 |  |
| 31 | 19 | Study on User Plane Congestion management |  | 136d? | 2011-12-14 | 2012-06-20 |  |  | 2011-12-14 | 2012-06-20 | 136d? | 394d | finish no earlier than 2012-06-20 | S1 | 1088h |  | Rel-12 | FS_UPCON | PCG-28 | KDDI | John Visser (xjo-visser@kddi.com) | SP-54 |  |
| 32 | 20 | Study on RAN Sharing Enhancements |  | 136d? | 2011-12-14 | 2012-06-20 |  |  | 2011-12-14 | 2012-06-20 | 136d? | 394d | finish no earlier than 2012-06-20 | S1 | 1088h |  | Rel-12 | FS_RSE | PCG-28 | NEC | joerg.swetina@nw.neclab.eu | SP-54 |  |

Notes:
- 1: -
- 2: -
- 3: -
- 4: -
- 5: -
- 6: -
- 7: -
- 8: - / Text3: 22.228
- 9: -
- 10: SP#54 completion 12/11=>06/12 / Text3: 22.278
- 11: SP#47 Stage 1 completed. Triggered by UID_370045 Study on enhanced voice service requirements for EPS (TR 22.813)
- 12: SP#47 completed. Covered by general requirements in 22.101, 22.001 / Text3: 22.173
- 13: SP#54 completion 03/13=>09/13 / Text3: 26.xyz, 26.xyz, 26.9yz
- 14: SP#54 moved to Rel-12. Linked to UID_490030 SIPTO Service Continuity of IP Data Session (SIPTO_SC), UID_450035 Local IP Access and Selected IP Traffic Offload (LIPA_SIPTO), UID_460026 Support BBF Accesses Interworking (BBAI)
- 15: SP#54 moved to Rel-12 (completion 06/12) / Text3: new TR 23.859
- 16: SP#54 moved to Rel-12 (completion 06/12) / Text3: 23.060, 23.401
- 17: CP#54 updated WID CP-110724=>CP-110801 moved to Rel-12 (completion 09/12=>12/13) / Text3: Stage 3
- 18: - / Text3: 29.002, 29.060, 29.272, 29.274, 29.275, 29.281, 29.282, 29.303, 29.305
- 19: - / Text3: 24.008, 24.301
- 20: CP#54 updated WID CP-110727=>CP-110820 moved to Rel-12 (completion 09/12=>12/13) / Text3: Stage 3
- 21: - / Text3: 24.008, 24.301
- 22: - / Text3: 29.060, 29.274, 29.281, 29.303, 29.002, 29.272, 29.275, 29.282, 29.305
- 23: -
- 24: SP#54 considered for deletion at SA1#57 if still no progress. Triggered by GSMA Smart SIM and 3GNBK projects, and to evolve from traditional USAT to multimedia USIM toolkit support, particularly to Smart Card Web Server / Text3: 22.817
- 25: SP#53 TR 22.988v100 for Information. Determine an alternative to E.164 for identifying individual devices and route messages between those devices / Text3: 22.988
- 26: SP#53 completion 09/11=>06/12. Study Network improvements for MTC Device to MTC Device communications via one or more PLMNs (direct-mode communication between devices is out of scope), etc. Align also with ETSI TC M2M work. / Text3: 22.888
- 27: SP#54 completion 12/11=>03/12. Linked to SA3 Study on Single Sign On (SSO) Application Security for IMS - based on SIP Digest (UID_480048), SA3 TR 33.924 Extended Identity Management (GBA-IdM) and SA3 TR 33.980 (LibSec) / Text3: 22.895
- 28: SP#54 completed. Linked to SA1 Rel-11 Feature UID_490030 SIPTO Service Continuity of IP Data Session (SIPTO_SC) / Text3: 22.896
- 29: SP#54 completed. Linked to UID_490036 SA2 Rel-11 TR 23.843 Study on Core Network Overload solutions (FS_CNO) / Text3: 22.801
- 30: - / Text3: 22.803
- 31: Linked to SAPP (Service Awareness and Privacy Policies) UID_500032, FS_UMONC (Study on Usage Monitoring Control Enhancement) UID_520035, QoS_SSL (QoS Control Based on Subscriber Spending Limits) UID_490031 / Text3: 22.805
- 32: Extend Rel-6 Network Sharing UID_31018 (basic scenarios of network/RAN sharing) to cover more complex scenarios that arise due to recent needs for more dynamic co-operation among operators. / Text3: 22.852

| ID | WBS | Task | Duration | Start | Finish | Complete | Remaining | Baseline start | Baseline finish | Baseline duration | Total slack | Constraint | Resources | Work | Actual work | Text1 | Text2 | Text3 | Text4 | Text6 | Text7 | Text8 |
| --- | --- | --- | --- | --- | --- | --- | --- | --- | --- | --- | --- | --- | --- | --- | --- | --- | --- | --- | --- | --- | --- | --- |
| 33 | 21 | **Study on Multi Access PDN connectivity and IP flow Mobility** | 1012.96d? | 2008-08-08 A | 2012-06-20 | 76% | 247.7d? | 2008-08-08 | 2012-06-20 | 1012.96d? | 394d |  | S2,S1 | 9776h | 7381.53h | FS_MAPIM | PCG-21 | 23.861 | Qualcomm, ZTE | Rel-12 | SP-41 | Maurice |
| 34 | 21.1 | SA1 part of FS_MAPIM | 22d? | 2008-08-08 A | 2011-09-21 A | 100% |  | 2008-08-08 | 2011-09-21 | 22d? |  | finish no earlier than 2011-09-21 | S1 | 160h | 160h | FS_MAPIM | PCG-21 | 23.861 | Qualcomm, ZTE | Rel-12 | SP-41 | Maurice |
| 35 | 21.2 | SA2 part of FS_MAPIM | 984d? | 2008-09-18 A | 2012-06-20 | 75% | 246d? | 2008-09-18 | 2012-06-20 | 984d? | 394d | finish no earlier than 2012-06-20 | S2 | 7872h | 5904h | FS_MAPIM | PCG-21 | 23.861 | Qualcomm, ZTE | Rel-12 | SP-41 | Maurice |
| 36 | 22 | **Study on Usage Monitoring Control enhancement** | 339d? | 2011-06-08 A | 2012-09-19 | 8% | 311.14d? | 2011-06-08 | 2012-09-19 | 339d? | 329d |  | S2,S1,S5 | 5970.09h | 1198.05h | FS_UMONC | PCG-27 |  | ZTE, Huawei | Rel-12 | SP-52 | Maurice |
| 37 | 22.1 | SA2,SA1 part of FS_UMONC | 274d? | 2011-06-08 | 2012-06-20 |  |  | 2011-06-08 | 2012-06-20 | 274d? | 394d | finish no earlier than 2012-06-20 | S2,S1 | 2170.08h |  | FS_UMONC | PCG-27 | 23.858 | ZTE | Rel-12 | SP-52 | Maurice |
| 38 | 22.2 | SA5 part of FS_UMONC | 332d? | 2011-06-08 A | 2012-09-19 | 15% | 282.2d? | 2011-06-08 | 2012-09-19 | 332d? | 329d | finish no earlier than 2012-09-19 | S5 | 1088h | 382.4h | FS_UMONC | PCG-27 | 32.858 | Huawei | Rel-12 | SP-52 | Dionisio |
| 39 | 23 | Study on Security aspects of Integration of Single Sign-On (SSO) frameworks with 3GPP networks | 521d? | 2010-12-16 A | 2012-12-12 | 25% | 390.75d? | 2010-12-16 | 2012-12-12 | 521d? | 269d | finish no earlier than 2012-12-12 | S3 | 4168h | 1042h | FS_SSO_Int_Sec | PCG-26 | 33.8xy | Ericsson | Rel-12 | SP-50 | Dionisio |
| 40 | 24 | Study on IMS Firewall Traversal | 391d? | 2011-06-17 A | 2012-12-12 | 13% | 341.35d? | 2011-06-17 | 2012-12-12 | 391d? | 269d | finish no earlier than 2012-12-12 | S3 | 2648h | 397.2h | FS_iFire | PCG-27 | 33.8xy | Acme Packet | Rel-12 | SP-53 |  |

Notes:
- 33: SP#54 moved to Rel-12 (completion 03/12=>06/12). SP#43 TR 23.861v100 for Information. Spin-off UID_430035 MAPCON and UID_450041 IFOM / Text5: Gerardo Giaretta (gerardog@qualcomm.com), Tricci So (tso@zteusa.com)
- 34: SP#53 completed / Text5: Gerardo Giaretta (gerardog@qualcomm.com), Tricci So (tso@zteusa.com)
- 35: - / Text5: Gerardo Giaretta (gerardog@qualcomm.com), Tricci So (tso@zteusa.com)
- 36: SP#54 moved to Rel-12 (completion 12/11=>06/12)
- 37: - / Text5: SA2 Zaifeng Zong (zong.zaifeng@zte.com.cn), SA1 Mian Li (Li.Mian@zte.com.cn)
- 38: - / Text5: Hui Cai (Sarah.Cai@huawei.com)
- 39: SP#54 moved to Rel-12 (completion 03/12=>12/12) / Text5: vesa.lehtovirta@ericsson.com
- 40: SP#54 moved to Rel-12 (completion 03/12=>12/12) / Text5: Prashant Kumar (PKumar@acmepacket.com)
